# GlueX Software

Schedule from GanttProject, 2004-06-19 to 2007-07-04.
GlueX

## Calendars

- Project calendar: Mon-Fri working; Sat-Sun off.

## Schedule

| ID | WBS | Task | Duration | Start | Finish | Predecessors | Complete |
| --- | --- | --- | --- | --- | --- | --- | --- |
| 1 | 1 | **Offline Analysis** | 793d | 2004-06-19 | 2007-07-04 |  | 29% |
| 2 | 1.1 | **Tracking** | 359d | 2005-02-28 | 2006-07-13 |  | 15% |
| 3 | 1.1.1 | Pattern Recognition | 120d | 2005-02-28 | 2005-08-12 |  | 65% |
| 4 | 1.1.2 | Fitting (Kalman Filter) | 150d | 2005-06-28 | 2006-01-23 | 3 |  |
| 5 | 1.1.3 | Subsystem Preprocessing | 150d | 2005-06-01 | 2005-12-27 |  |  |
| 6 | 1.1.4 | Full Tracking | 90d | 2005-11-24 | 2006-03-29 | 4, 8, 10, 12 |  |
| 7 | 1.2 | **Calorimetry** | 390d | 2005-06-01 | 2006-11-28 |  | 42% |
| 8 | 1.2.1 | Reconstruction w/ Clean Hits | 120d | 2005-06-01 | 2005-11-15 |  | 25% |
| 9 | 1.2.2 | Reconstruction w/ Smeared Tracks | 270d | 2005-09-29 | 2006-10-11 | 8 | 50% |
| 10 | 1.3 | TOF | 90d | 2005-06-01 | 2005-10-04 |  |  |
| 11 | 1.4 | PID | 180d | 2006-02-22 | 2006-10-31 | 6, 10 |  |
| 12 | 1.5 | Magnetic Field | 30d | 2005-05-12 | 2005-06-22 |  | 40% |
| 13 | 1.6 | Analysis Framework | 365d | 2004-06-19 | 2005-11-11 |  | 75% |
| 14 | 1.7 | Event Viewer | 180d | 2005-05-02 | 2006-01-06 |  | 10% |
| 15 | 1.8 | Calibration/Parameters Database | 90d | 2005-06-01 | 2005-10-04 |  |  |
| 16 | 2 | GRID services | 1d | 2005-05-12 | 2005-05-12 |  |  |
| 17 | 3 | GEANT4 | 365d | 2005-08-31 | 2007-01-23 |  |  |
| 18 | 4 | Tagger Simulation/Reconstruction | 180d | 2005-06-01 | 2006-02-07 |  |  |
| 19 | 5 | PWA | 1d | 2005-05-12 | 2005-05-12 |  |  |
| 20 | 6 | Online | 1d | 2005-05-12 | 2005-05-12 |  | 1% |
